# Office Remodel

How a schedule from MS Project changed from version to version. A marks actual dates.

## Version 1 (data date 2014-01-11, saved 2016-05-11, file 9formatting.mpp)

| ID | WBS | Task | Duration | Start | Finish | Predecessors | Complete | Total float | Constraint |
| --- | --- | --- | --- | --- | --- | --- | --- | --- | --- |
| 1 | 1 | **Office Workspace Remodel** | 27d | 2017-10-09 A | 2017-11-15 |  | 88% | 0d |  |
| 2 | 1.1 | **Space planning** | 13d | 2017-10-09 A | 2017-10-25 A |  | 100% |  |  |
| 3 |  | Interview space planners | 1w | 2017-10-09 A | 2017-10-13 A |  | 100% |  |  |
| 4 |  | Hire space planner | 1d | 2017-10-16 A | 2017-10-16 A | 3 | 100% |  |  |
| 5 |  | Meeting with space planner | 3d | 2017-10-17 A | 2017-10-19 A | 4 | 100% |  |  |
| 6 |  | Finalize space plan | 3d | 2017-10-23 A | 2017-10-25 A | 5 | 100% |  |  |
| 7 |  | Space plan complete | 0d | 2017-10-24 A | 2017-10-24 A | 6 | 100% |  |  |
| 8 | 1.2 | **Furniture selection** | 10.5d | 2017-10-23 A | 2017-11-06 A |  | 100% |  |  |
| 9 |  | Preview furniture selections | 2d | 2017-10-23 A | 2017-10-24 A | 5SS+1d | 100% |  |  |
| 10 |  | Select new furniture | 1.5d | 2017-10-24 A | 2017-10-25 A | 9 | 100% |  |  |
| 11 |  | Order new furniture | 0.5d | 2017-10-25 A | 2017-10-25 A | 10 | 100% |  |  |
| 12 |  | Delivery time | 1.5w | 2017-10-26 A | 2017-11-06 A | 11 | 100% |  | finish no earlier than 2015-11-04 |
| 13 |  | Furniture delivered | 0d | 2017-11-03 A | 2017-11-03 A | 12 | 100% |  |  |
| 14 | 1.3 | **Remodel workspace** | 9d | 2017-10-25 A | 2017-11-07 |  | 94% | 6d |  |
| 15 |  | Hire contractor | 4d | 2017-10-25 A | 2017-10-30 A | 7 | 100% |  |  |
| 16 |  | Remodel workspace | 1w | 2017-10-31 A | 2017-11-06 | 15 | 90% | 1.5d |  |
| 17 |  | Remodel complete | 0d | 2017-11-07 | 2017-11-07 | 16 |  | 6d | start no earlier than 2017-11-07 |
| 18 | 1.4 | **New workspace** | 15d | 2017-10-25 A | 2017-11-14 |  | 57% | 0d |  |
| 19 |  | Hire mover | 4d | 2017-10-25 A | 2017-10-30 A | 15SS | 100% |  |  |
| 20 |  | Pack workspace | 1d | 2017-10-31 A | 2017-10-31 A | 19, 15 | 100% |  |  |
| 21 |  | Move Equipment | 0.5d | 2017-10-31 A | 2017-10-31 A | 20FF | 100% |  |  |
| 22 |  | Remove existing furniture | 1d | 2017-11-01 A | 2017-11-01 A | 21 | 100% |  |  |
| 23 |  | Assemble new furniture | 2d | 2017-11-07 | 2017-11-08 | 22, 16 |  | 1.5d |  |
| 24 |  | Return equipment | 1d | 2017-11-08 | 2017-11-09 | 23FS-0.5d |  | 1.5d |  |
| 25 |  | Unpack workspace | 1d | 2017-11-13 | 2017-11-13 | 24 |  | 0d | start no earlier than 2017-11-11 |
| 26 |  | Workspace final clean | 1d | 2017-11-14 | 2017-11-14 | 25 |  | 0d | start no earlier than 2017-11-11 |
| 27 |  | Workspace remodel complete | 0d | 2017-11-15 | 2017-11-15 | 18 |  | 0d | start no earlier than 2017-11-15 |

## Version 2 (saved 2016-05-21, file 2outline.mpp)

Last finish 2017-11-15 → 2017-10-20 (-26d). Complete tasks 15 → 0.

Removed: 4 Hire space planner; 11 Order new furniture

Changed:

| ID | Task | Start | Finish | Duration | Complete | Total float | Predecessors | Other |
| --- | --- | --- | --- | --- | --- | --- | --- | --- |
| 1 | Office Workspace Remodel | 2017-10-09 A → 2017-10-09 | 2017-11-15 → 2017-10-09 (-37d) | 27d → 1d | 88% → 0% | 0d → 9d |  |  |
| 2 | Space planning | 2017-10-09 A → 2017-10-09 | 2017-10-25 A → 2017-10-09 (-16d) | 13d → 1d | 100% → 0% | none → 9d |  |  |
| 3 | Interview space planners | 2017-10-09 A → 2017-10-09 | 2017-10-13 A → 2017-10-13 |  | 100% → 0% | none → 5d |  | resources Operations Manager; Office Manager; President [25%] → none |
| 4 | Meeting with space planner | 2017-10-17 A → 2017-10-09 (-8d) | 2017-10-19 A → 2017-10-10 (-9d) | 3d → 2d | 100% → 0% | none → 8d | Hire space planner → none | resources President; Office Manager; Administrative Assistant; Operations Manager; Space Planner → none |
| 5 | Furniture delivered | 2017-11-03 A → 2017-10-09 (-25d) | 2017-11-03 A → 2017-10-09 (-25d) |  | 100% → 0% | none → 10d | 11 → none |  |
| 6 | Finalize space plan | 2017-10-23 A → 2017-10-09 (-14d) | 2017-10-25 A → 2017-10-11 (-14d) |  | 100% → 0% | none → 7d | 4 → none | resources Space Planner → none |
| 7 | Space plan complete | 2017-10-24 A → 2017-10-09 (-15d) | 2017-10-24 A → 2017-10-09 (-15d) |  | 100% → 0% | none → 10d | 6 → none |  |
| 8 | Furniture selection | 2017-10-23 A → 2017-10-09 (-14d) | 2017-11-06 A → 2017-10-09 (-28d) | 10.5d → 1d | 100% → 0% | none → 9d |  |  |
| 9 | Preview furniture selections | 2017-10-23 A → 2017-10-09 (-14d) | 2017-10-24 A → 2017-10-10 (-14d) |  | 100% → 0% | none → 8d | 4SS+1d → none | resources Office Manager; Operations Manager; Administrative Assistant → none |
| 10 | Select new furniture | 2017-10-24 A → 2017-10-09 (-15d) | 2017-10-25 A → 2017-10-10 (-15d) | 1.5d → 2d | 100% → 0% | none → 8d | 9 → none | resources Office Manager; Operations Manager → none |
| 11 | Delivery time | 2017-10-26 A → 2017-10-09 (-17d) | 2017-11-06 A → 2017-10-18 (-19d) |  | 100% → 0% | none → 2.5d | Order new furniture → none | constraint finish no earlier than 2015-11-04 → none; resources Administrative Assistant [10%] → none |
| 12 | Remodel workspace | 2017-10-25 A → 2017-10-09 (-16d) | 2017-11-07 → 2017-10-09 (-29d) | 9d → 1d | 94% → 0% | 6d → 9d |  |  |
| 13 | Hire contractor | 2017-10-25 A → 2017-10-09 (-16d) | 2017-10-30 A → 2017-10-12 (-18d) |  | 100% → 0% | none → 6d | 7 → none | resources President; Operations Manager → none |
| 14 | Remodel workspace | 2017-10-31 A → 2017-10-09 (-22d) | 2017-11-06 → 2017-10-20 (-17d) | 1w → 2w | 90% → 0% | 1.5d → 0d | 13 → none | resources Contractor [200%] → none |
| 15 | Remodel complete | 2017-11-07 → 2017-10-09 (-29d) | 2017-11-07 → 2017-10-09 (-29d) |  |  | 6d → 10d | 14 → none | constraint start no earlier than 2017-11-07 → none |
| 16 | New workspace | 2017-10-25 A → 2017-10-09 (-16d) | 2017-11-14 → 2017-10-09 (-36d) | 15d → 1d | 57% → 0% | 0d → 9d |  |  |
| 17 | Hire mover | 2017-10-25 A → 2017-10-09 (-16d) | 2017-10-30 A → 2017-10-10 (-20d) | 4d → 2d | 100% → 0% | none → 8d | 13SS → none | resources Office Manager → none |
| 18 | Pack workspace | 2017-10-31 A → 2017-10-09 (-22d) | 2017-10-31 A → 2017-10-09 (-22d) |  | 100% → 0% | none → 9d | 17, 13 → none | resources President; Janitor → none |
| 19 | Move equipment | 2017-10-31 A → 2017-10-09 (-22d) | 2017-10-31 A → 2017-10-09 (-22d) |  | 100% → 0% | none → 9.5d | 18FF → none | was named Move Equipment; resources Mover; Operations Manager → none |
| 20 | Remove existing furniture | 2017-11-01 A → 2017-10-09 (-23d) | 2017-11-01 A → 2017-10-09 (-23d) |  | 100% → 0% | none → 9d | 19 → none | resources Mover → none |
| 21 | Assemble new furniture | 2017-11-07 → 2017-10-09 (-29d) | 2017-11-08 → 2017-10-10 (-29d) |  |  | 1.5d → 8d | 20, 14 → none | resources Office Manager; Space Planner [116.7%] → none |
| 22 | Return equipment | 2017-11-08 → 2017-10-09 (-30d) | 2017-11-09 → 2017-10-09 (-31d) |  |  | 1.5d → 9d | 21FS-0.5d → none | resources Mover; Operations Manager → none |
| 23 | Unpack workspace | 2017-11-13 → 2017-10-09 (-35d) | 2017-11-13 → 2017-10-09 (-35d) |  |  | 0d → 9d | 22 → none | constraint start no earlier than 2017-11-11 → none; resources Mover; Administrative Assistant → none |
| 24 | Workspace final clean | 2017-11-14 → 2017-10-09 (-36d) | 2017-11-14 → 2017-10-09 (-36d) |  |  | 0d → 9d | 23 → none | constraint start no earlier than 2017-11-11 → none; resources Janitor [50%]; Mover [50%] → none |
| 25 | Workspace remodel complete | 2017-11-15 → 2017-10-09 (-37d) | 2017-11-15 → 2017-10-09 (-37d) |  |  | 0d → 10d | 16 → none | constraint start no earlier than 2017-11-15 → none |

## Version 3 (saved 2016-05-21, file 3rescal.mpp)

Last finish 2017-10-20 → 2017-11-24 (+35d).

Added:

| ID | Task | Duration | Start | Finish | Predecessors | Resources |
| --- | --- | --- | --- | --- | --- | --- |
| 4 | Hire space planner | 2d | 2017-10-16 | 2017-10-17 | 3 | President; Administrative Assistant |
| 11 | Order new furniture | 0.5d | 2017-10-25 | 2017-10-25 | 10 | Administrative Assistant |

Changed:

| ID | Task | Start | Finish | Duration | Total float | Predecessors | Other |
| --- | --- | --- | --- | --- | --- | --- | --- |
| 1 | **Office Workspace Remodel** |  | 2017-10-09 → 2017-11-24 (+46d) | 1d → 34.5d | 9d → 0d |  |  |
| 2 | **Space planning** |  | 2017-10-09 → 2017-10-24 (+15d) | 1d → 12d | 9d → 0d |  |  |
| 3 | Interview space planners |  |  |  | 5d → 0d |  | resources none → President; Operations Manager; Office Manager |
| 5 | Meeting with space planner | 2017-10-09 → 2017-10-18 (+9d) | 2017-10-10 → 2017-10-19 (+9d) |  | 8d → 0d | none → 4 | resources none → President; Office Manager; Administrative Assistant; Operations Manager; Space Planner |
| 6 | Finalize space plan | 2017-10-09 → 2017-10-20 (+11d) | 2017-10-11 → 2017-10-24 (+13d) |  | 7d → 0d | none → 5 | resources none → Space Planner |
| 7 | Space plan complete | 2017-10-09 → 2017-10-24 (+15d) | 2017-10-09 → 2017-10-24 (+15d) |  | 10d → 0d | none → 6 |  |
| 8 | **Furniture selection** | 2017-10-09 → 2017-10-19 (+10d) | 2017-10-09 → 2017-11-03 (+25d) | 1d → 12d | 9d → 14.5d |  |  |
| 9 | Preview furniture selections | 2017-10-09 → 2017-10-19 (+10d) | 2017-10-10 → 2017-10-20 (+10d) |  | 8d → 14.5d | none → 5SS+1d | resources none → Office Manager; Operations Manager; Administrative Assistant |
| 10 | Select new furniture | 2017-10-09 → 2017-10-23 (+14d) | 2017-10-10 → 2017-10-24 (+14d) |  | 8d → 14.5d | none → 9 | resources none → Office Manager; Operations Manager |
| 12 | Delivery time | 2017-10-09 → 2017-10-25 (+16d) | 2017-10-18 → 2017-11-03 (+16d) |  | 2.5d → 14.5d | none → 11 | resources none → Administrative Assistant [10%] |
| 13 | Furniture delivered | 2017-10-09 → 2017-11-03 (+25d) | 2017-10-09 → 2017-11-03 (+25d) |  | 10d → 14.5d | none → 12 |  |
| 14 | **Remodel workspace** | 2017-10-09 → 2017-10-25 (+16d) | 2017-10-09 → 2017-11-13 (+35d) | 1d → 14d | 9d → 0d |  |  |
| 15 | Hire contractor | 2017-10-09 → 2017-10-25 (+16d) | 2017-10-12 → 2017-10-30 (+18d) |  | 6d → 0d | none → 7 | resources none → President; Operations Manager |
| 16 | Remodel workspace | 2017-10-09 → 2017-10-31 (+22d) | 2017-10-20 → 2017-11-13 (+24d) |  |  | none → 15 | resources none → Contractor |
| 17 | Remodel complete | 2017-10-09 → 2017-11-13 (+35d) | 2017-10-09 → 2017-11-13 (+35d) |  | 10d → 0d | none → 16 |  |
| 18 | **New workspace** | 2017-10-09 → 2017-11-14 (+36d) | 2017-10-09 → 2017-11-24 (+46d) | 1d → 8.5d | 9d → 0d | none → 14 |  |
| 19 | Hire mover | 2017-10-09 → 2017-11-14 (+36d) | 2017-10-10 → 2017-11-15 (+36d) |  | 8d → 0d |  | resources none → Office Manager; Operations Manager |
| 20 | Pack workspace | 2017-10-09 → 2017-11-16 (+38d) | 2017-10-09 → 2017-11-16 (+38d) |  | 9d → 0d | none → 19 | resources none → Operations Manager; Mover |
| 21 | Move Equipment | 2017-10-09 → 2017-11-16 (+38d) | 2017-10-09 → 2017-11-16 (+38d) |  | 9.5d → 0d | none → 20FF | was named Move equipment; resources none → Mover; Operations Manager |
| 22 | Remove existing furniture | 2017-10-09 → 2017-11-17 (+39d) | 2017-10-09 → 2017-11-17 (+39d) |  | 9d → 0d | none → 21 | resources none → Mover |
| 23 | Assemble new furniture | 2017-10-09 → 2017-11-20 (+42d) | 2017-10-10 → 2017-11-21 (+42d) |  | 8d → 0d | none → 22 | resources none → Mover; Space Planner |
| 24 | Return equipment | 2017-10-09 → 2017-11-21 (+43d) | 2017-10-09 → 2017-11-22 (+44d) |  | 9d → 0d | none → 23FS-0.5d | resources none → Mover; Operations Manager |
| 25 | Unpack workspace | 2017-10-09 → 2017-11-22 (+44d) | 2017-10-09 → 2017-11-23 (+45d) |  | 9d → 0d | none → 24 | resources none → Mover; Administrative Assistant |
| 26 | Workspace final clean | 2017-10-09 → 2017-11-23 (+45d) | 2017-10-09 → 2017-11-24 (+46d) |  | 9d → 0d | none → 25 | resources none → Janitor |
| 27 | Workspace remodel complete | 2017-10-09 → 2017-11-24 (+46d) | 2017-10-09 → 2017-11-24 (+46d) |  | 10d → 0d | none → 18 |  |

## Version 4 (saved 2016-05-22, file 3resource.mpp)

Last finish stays 2017-11-24.

Changed:

| ID | Task | Other |
| --- | --- | --- |
| 3 | Interview space planners | resources President; Operations Manager; Office Manager → none |
| 4 | Hire space planner | resources President; Administrative Assistant → none |
| 5 | Meeting with space planner | resources President; Office Manager; Administrative Assistant; Operations Manager; Space Planner → none |
| 6 | Finalize space plan | resources Space Planner → none |
| 9 | Preview furniture selections | resources Office Manager; Operations Manager; Administrative Assistant → none |
| 10 | Select new furniture | resources Office Manager; Operations Manager → none |
| 11 | Order new furniture | resources Administrative Assistant → none |
| 12 | Delivery time | resources Administrative Assistant [10%] → none |
| 15 | Hire contractor | resources President; Operations Manager → none |
| 16 | Remodel workspace | resources Contractor → none |
| 19 | Hire mover | resources Office Manager; Operations Manager → none |
| 20 | Pack workspace | resources Operations Manager; Mover → none |
| 21 | Move equipment | was named Move Equipment; resources Mover; Operations Manager → none |
| 22 | Remove existing furniture | resources Mover → none |
| 23 | Assemble new furniture | resources Mover; Space Planner → none |
| 24 | Return equipment | resources Mover; Operations Manager → none |
| 25 | Unpack workspace | resources Mover; Administrative Assistant → none |
| 26 | Workspace final clean | resources Janitor → none |

## Version 5 (saved 2016-05-26, file 5constraint.mpp)

Last finish 2017-11-24 → 2017-11-20 (-4d).

Changed:

| ID | Task | Start | Finish | Duration | Total float | Other |
| --- | --- | --- | --- | --- | --- | --- |
| 1 | **Office Workspace Remodel** |  | 2017-11-24 → 2017-11-20 (-4d) | 34.5d → 31d |  |  |
| 3 | Interview space planners |  |  |  | 0d → 0.88d | resources none → President; Operations Manager; Office Manager |
| 4 | Hire space planner |  |  |  | 0d → 0.88d | resources none → President; Administrative Assistant |
| 5 | Meeting with space planner |  |  |  | 0d → 0.88d | resources none → President; Office Manager; Administrative Assistant; Operations Manager; Space Planner |
| 6 | Finalize space plan |  |  |  | 0d → 0.88d | resources none → Space Planner |
| 8 | **Furniture selection** |  | 2017-11-03 → 2017-11-02 (-1d) | 12d → 11d | 14.5d → 12d |  |
| 9 | Preview furniture selections |  |  |  | 14.5d → 12d | resources none → Office Manager; Operations Manager; Administrative Assistant |
| 10 | Select new furniture |  | 2017-10-24 → 2017-10-23 (-1d) | 2d → 1d | 14.5d → 12d | resources none → Office Manager; Operations Manager |
| 11 | Order new furniture | 2017-10-25 → 2017-10-24 (-1d) | 2017-10-25 → 2017-10-24 (-1d) |  | 14.5d → 12d | resources none → Administrative Assistant |
| 12 | Delivery time | 2017-10-25 → 2017-10-24 (-1d) | 2017-11-03 → 2017-11-02 (-1d) |  | 14.5d → 12d | resources none → Administrative Assistant [10%] |
| 13 | Furniture delivered | 2017-11-03 → 2017-11-02 (-1d) | 2017-11-03 → 2017-11-02 (-1d) |  | 14.5d → 12d |  |
| 14 | **Remodel workspace** |  | 2017-11-13 → 2017-11-06 (-7d) | 14d → 9d | 0d → 0.88d |  |
| 15 | Hire contractor |  |  |  | 0d → 0.88d | resources none → President; Operations Manager |
| 16 | Remodel workspace |  | 2017-11-13 → 2017-11-06 (-7d) | 2w → 1w | 0d → 0.88d | resources none → Contractor [200%] |
| 17 | Remodel complete | 2017-11-13 → 2017-11-06 (-7d) | 2017-11-13 → 2017-11-06 (-7d) |  | 0d → 0.88d |  |
| 18 | **New workspace** | 2017-11-14 → 2017-11-07 (-7d) | 2017-11-24 → 2017-11-20 (-4d) | 8.5d → 10d |  |  |
| 19 | Hire mover | 2017-11-14 → 2017-11-07 (-7d) | 2017-11-15 → 2017-11-08 (-7d) |  | 0d → 0.88d | resources none → Office Manager; Operations Manager |
| 20 | Pack workspace | 2017-11-16 → 2017-11-09 (-7d) | 2017-11-16 → 2017-11-09 (-7d) |  | 0d → 0.88d | resources none → Operations Manager; Mover |
| 21 | Move Equipment | 2017-11-16 → 2017-11-09 (-7d) | 2017-11-16 → 2017-11-09 (-7d) |  | 0d → 0.88d | was named Move equipment; resources none → Mover; Operations Manager |
| 22 | Remove existing furniture | 2017-11-17 → 2017-11-09 (-8d) | 2017-11-17 → 2017-11-13 (-4d) |  | 0d → 0.38d | resources none → Mover |
| 23 | Assemble new furniture | 2017-11-20 → 2017-11-14 (-6d) | 2017-11-21 → 2017-11-15 (-6d) |  |  | resources none → Mover; Space Planner |
| 24 | Return equipment | 2017-11-21 → 2017-11-15 (-6d) | 2017-11-22 → 2017-11-16 (-6d) |  |  | resources none → Mover; Operations Manager |
| 25 | Unpack workspace | 2017-11-22 → 2017-11-16 (-6d) | 2017-11-23 → 2017-11-17 (-6d) |  |  | resources none → Mover; Administrative Assistant |
| 26 | Workspace final clean | 2017-11-23 → 2017-11-17 (-6d) | 2017-11-24 → 2017-11-20 (-4d) | 1d → 1.5d |  | resources none → Janitor [50%]; Mover [50%] |
| 27 | Workspace remodel complete | 2017-11-24 → 2017-11-20 (-4d) | 2017-11-24 → 2017-11-20 (-4d) |  |  |  |

## Version 6 (saved 2016-05-28, file 5tasktype.mpp)

Last finish 2017-11-20 → 2017-11-27 (+7d).

Changed:

| ID | Task | Start | Finish | Duration | Total float | Other |
| --- | --- | --- | --- | --- | --- | --- |
| 1 | **Office Workspace Remodel** |  | 2017-11-20 → 2017-11-27 (+7d) | 31d → 36d |  |  |
| 8 | **Furniture selection** | 2017-10-19 → 2017-10-20 (+1d) | 2017-11-02 → 2017-11-06 (+4d) | 11d → 12d | 12d → 15d |  |
| 9 | Preview furniture selections | 2017-10-19 → 2017-10-20 (+1d) | 2017-10-20 → 2017-10-23 (+3d) |  | 12d → 15d |  |
| 10 | Select new furniture | 2017-10-23 → 2017-10-24 (+1d) | 2017-10-23 → 2017-10-25 (+2d) | 1d → 2d | 12d → 15d | resources Office Manager; Operations Manager → Office Manager |
| 11 | Order new furniture | 2017-10-24 → 2017-10-26 (+2d) | 2017-10-24 → 2017-10-26 (+2d) |  | 12d → 15d |  |
| 12 | Delivery time | 2017-10-24 → 2017-10-26 (+2d) | 2017-11-02 → 2017-11-06 (+4d) |  | 12d → 15d |  |
| 13 | Furniture delivered | 2017-11-02 → 2017-11-06 (+4d) | 2017-11-02 → 2017-11-06 (+4d) |  | 12d → 15d |  |
| 14 | **Remodel workspace** |  | 2017-11-06 → 2017-11-13 (+7d) | 9d → 14d | 0.88d → 0d |  |
| 16 | Remodel workspace |  | 2017-11-06 → 2017-11-13 (+7d) | 1w → 2w | 0.88d → 0d | resources Contractor [200%] → Contractor |
| 17 | Remodel complete | 2017-11-06 → 2017-11-13 (+7d) | 2017-11-06 → 2017-11-13 (+7d) |  | 0.88d → 0d |  |
| 18 | **New workspace** | 2017-11-07 → 2017-11-14 (+7d) | 2017-11-20 → 2017-11-27 (+7d) |  |  |  |
| 19 | Hire mover | 2017-11-07 → 2017-11-14 (+7d) | 2017-11-08 → 2017-11-15 (+7d) |  | 0.88d → 0d |  |
| 20 | Pack workspace | 2017-11-09 → 2017-11-16 (+7d) | 2017-11-09 → 2017-11-16 (+7d) |  | 0.88d → 0d |  |
| 21 | Move Equipment | 2017-11-09 → 2017-11-17 (+8d) | 2017-11-09 → 2017-11-17 (+8d) |  | 0.88d → 0.38d |  |
| 22 | Remove existing furniture | 2017-11-09 → 2017-11-17 (+8d) | 2017-11-13 → 2017-11-20 (+7d) |  | 0.38d → 0d |  |
| 23 | Assemble new furniture | 2017-11-14 → 2017-11-21 (+7d) | 2017-11-15 → 2017-11-22 (+7d) |  |  |  |
| 24 | Return equipment | 2017-11-15 → 2017-11-22 (+7d) | 2017-11-16 → 2017-11-23 (+7d) | 1d → 1.5d |  |  |
| 25 | Unpack workspace | 2017-11-16 → 2017-11-24 (+8d) | 2017-11-17 → 2017-11-24 (+7d) |  |  |  |
| 26 | Workspace final clean | 2017-11-17 → 2017-11-27 (+10d) | 2017-11-20 → 2017-11-27 (+7d) | 1.5d → 1d |  | resources Janitor [50%]; Mover [50%] → Janitor |
| 27 | Workspace remodel complete | 2017-11-20 → 2017-11-27 (+7d) | 2017-11-20 → 2017-11-27 (+7d) |  |  |  |

## Version 7 (saved 2016-05-28, file 5critical.mpp)

Last finish 2017-11-27 → 2017-11-22 (-5d).

Changed:

| ID | Task | Start | Finish | Duration | Total float | Predecessors | Other |
| --- | --- | --- | --- | --- | --- | --- | --- |
| 1 | **Office Workspace Remodel** |  | 2017-11-27 → 2017-11-22 (-5d) | 36d → 32d |  |  |  |
| 5 | Meeting w/space planner |  |  |  |  |  | was named Meeting with space planner |
| 8 | **Furniture selection** | 2017-10-20 → 2017-10-19 (-1d) | 2017-11-06 → 2017-11-02 (-4d) | 12d → 11d | 15d → 13d |  |  |
| 9 | Preview furniture selections | 2017-10-20 → 2017-10-19 (-1d) | 2017-10-23 → 2017-10-20 (-3d) |  | 15d → 13d |  |  |
| 10 | Select new furniture | 2017-10-24 → 2017-10-23 (-1d) | 2017-10-25 → 2017-10-23 (-2d) | 2d → 1d | 15d → 13d |  | resources Office Manager → Office Manager; Operations Manager |
| 11 | Order new furniture | 2017-10-26 → 2017-10-24 (-2d) | 2017-10-26 → 2017-10-24 (-2d) |  | 15d → 13d |  |  |
| 12 | Delivery time | 2017-10-26 → 2017-10-24 (-2d) | 2017-11-06 → 2017-11-02 (-4d) |  | 15d → 13d |  | constraint none → finish no earlier than 2013-11-03 |
| 13 | Furniture delivered | 2017-11-06 → 2017-11-02 (-4d) | 2017-11-06 → 2017-11-02 (-4d) |  | 15d → 13d |  |  |
| 14 | **Remodel workspace** |  | 2017-11-13 → 2017-11-06 (-7d) | 14d → 9d | 0d → 0.88d |  |  |
| 16 | Remodel workspace |  | 2017-11-13 → 2017-11-06 (-7d) | 2w → 1w | 0d → 0.88d |  | resources Contractor → Contractor [200%] |
| 17 | Remodel complete | 2017-11-13 → 2017-11-06 (-7d) | 2017-11-13 → 2017-11-06 (-7d) |  | 0d → 0.88d |  |  |
| 18 | **New workspace** | 2017-11-14 → 2017-11-07 (-7d) | 2017-11-27 → 2017-11-21 (-6d) | 10d → 11d |  |  |  |
| 19 | Hire mover | 2017-11-14 → 2017-11-07 (-7d) | 2017-11-15 → 2017-11-08 (-7d) |  | 0d → 0.88d |  |  |
| 20 | Pack workspace | 2017-11-16 → 2017-11-09 (-7d) | 2017-11-16 → 2017-11-09 (-7d) |  | 0d → 0.88d |  |  |
| 21 | Move Equipment | 2017-11-17 → 2017-11-09 (-8d) | 2017-11-17 → 2017-11-09 (-8d) |  | 0.38d → 0.88d |  |  |
| 22 | Remove existing furniture | 2017-11-17 → 2017-11-09 (-8d) | 2017-11-20 → 2017-11-13 (-7d) |  | 0d → 0.38d |  |  |
| 23 | Assemble new furniture | 2017-11-21 → 2017-11-14 (-7d) | 2017-11-22 → 2017-11-15 (-7d) |  |  |  |  |
| 24 | Return equipment | 2017-11-22 → 2017-11-16 (-6d) | 2017-11-23 → 2017-11-16 (-7d) | 1.5d → 1d |  | 23FS-0.5d → 23 |  |
| 25 | Unpack workspace | 2017-11-24 → 2017-11-17 (-7d) | 2017-11-24 → 2017-11-20 (-4d) | 1d → 2d |  |  |  |
| 26 | Workspace final clean | 2017-11-27 → 2017-11-21 (-6d) | 2017-11-27 → 2017-11-21 (-6d) |  |  |  | resources Janitor → Janitor [50%]; Mover [50%] |
| 27 | Workspace remodel complete | 2017-11-27 → 2017-11-22 (-5d) | 2017-11-27 → 2017-11-22 (-5d) |  |  | 18 → 18, 26 | constraint none → must finish on 2017-11-22 |

## Version 8 (saved 2016-05-28, file 6contours.mpp)

Last finish stays 2017-11-22.

Changed:

| ID | Task | Start | Duration | Total float | Predecessors | Other |
| --- | --- | --- | --- | --- | --- | --- |
| 3 | Interview space planners |  |  | 0d → 0.88d |  | resources President; Operations Manager; Office Manager → Operations Manager; Office Manager; President [25%] |
| 5 | Meeting with space planner |  |  | 0d → 0.88d |  | was named Meeting w/space planner |
| 18 | **New workspace** |  | 11d → 10.5d | 0d → 0.5d |  |  |
| 19 | Hire mover |  |  |  | none → 15SS |  |
| 20 | Pack workspace |  |  |  | 19 → 19, 15 |  |
| 23 | Assemble new furniture |  |  |  | 22 → 22, 16 |  |
| 24 | Return equipment | 2017-11-16 → 2017-11-15 (-1d) |  | 0d → 0.5d | 23 → 23FS-0.5d |  |
| 25 | Unpack workspace | 2017-11-17 → 2017-11-16 (-1d) |  | 0d → 0.5d |  |  |
| 26 | Workspace final clean | 2017-11-21 → 2017-11-20 (-1d) |  | 0d → 0.5d |  |  |
| 27 | Workspace remodel complete |  |  |  | 18, 26 → 26 |  |

## Version 9 (saved 2016-05-29, file 2depend.mpp)

Last finish 2017-11-22 → 2017-11-27 (+5d).

Changed:

| ID | Task | Start | Finish | Duration | Total float | Predecessors | Other |
| --- | --- | --- | --- | --- | --- | --- | --- |
| 1 | **Office Workspace Remodel** |  | 2017-11-22 → 2017-11-27 (+5d) | 32d → 35.5d |  |  |  |
| 3 | Interview space planners |  |  |  | 0.88d → 0d |  | resources Operations Manager; Office Manager; President [25%] → none |
| 4 | Hire space planner |  |  |  | 0.88d → 0d |  | resources President; Administrative Assistant → none |
| 5 | Meeting with space planner |  |  |  | 0.88d → 0d |  | resources President; Office Manager; Administrative Assistant; Operations Manager; Space Planner → none |
| 6 | Finalize space plan |  |  |  | 0.88d → 0d |  | resources Space Planner → none |
| 8 | **Furniture selection** | 2017-10-19 → 2017-10-20 (+1d) | 2017-11-02 → 2017-11-06 (+4d) | 11d → 12d | 13d → 14.5d |  |  |
| 9 | Preview furniture selections | 2017-10-19 → 2017-10-20 (+1d) | 2017-10-20 → 2017-10-23 (+3d) |  | 13d → 14.5d | 5SS+1d → 5 | resources Office Manager; Operations Manager; Administrative Assistant → none |
| 10 | Select new furniture | 2017-10-23 → 2017-10-24 (+1d) | 2017-10-23 → 2017-10-25 (+2d) | 1d → 2d | 13d → 14.5d |  | resources Office Manager; Operations Manager → none |
| 11 | Order new furniture | 2017-10-24 → 2017-10-26 (+2d) | 2017-10-24 → 2017-10-26 (+2d) |  | 13d → 14.5d |  | resources Administrative Assistant → none |
| 12 | Delivery time | 2017-10-24 → 2017-10-26 (+2d) | 2017-11-02 → 2017-11-06 (+4d) |  | 13d → 14.5d |  | constraint finish no earlier than 2013-11-03 → none; resources Administrative Assistant [10%] → none |
| 13 | Furniture delivered | 2017-11-02 → 2017-11-06 (+4d) | 2017-11-02 → 2017-11-06 (+4d) |  | 13d → 14.5d |  |  |
| 14 | **Remodel workspace** |  | 2017-11-06 → 2017-11-13 (+7d) | 9d → 14d | 0.88d → 0d |  |  |
| 15 | Hire contractor |  |  |  | 0.88d → 0d |  | resources President; Operations Manager → none |
| 16 | Remodel workspace |  | 2017-11-06 → 2017-11-13 (+7d) | 1w → 2w | 0.88d → 0d |  | resources Contractor [200%] → none |
| 17 | Remodel complete | 2017-11-06 → 2017-11-13 (+7d) | 2017-11-06 → 2017-11-13 (+7d) |  | 0.88d → 0d |  |  |
| 18 | **New workspace** | 2017-11-07 → 2017-11-14 (+7d) | 2017-11-21 → 2017-11-27 (+6d) | 10.5d → 9.5d | 0.5d → 0d |  |  |
| 19 | Hire mover | 2017-11-07 → 2017-11-14 (+7d) | 2017-11-08 → 2017-11-15 (+7d) |  | 0.88d → 0d | 15SS → none | resources Office Manager; Operations Manager → none |
| 20 | Pack workspace | 2017-11-09 → 2017-11-16 (+7d) | 2017-11-09 → 2017-11-16 (+7d) |  | 0.88d → 0d | 19, 15 → 19 | resources Operations Manager; Mover → none |
| 21 | Move equipment | 2017-11-09 → 2017-11-17 (+8d) | 2017-11-09 → 2017-11-17 (+8d) |  | 0.88d → 0d | 20FF → 20 | was named Move Equipment; resources Mover; Operations Manager → none |
| 22 | Remove existing furniture | 2017-11-09 → 2017-11-17 (+8d) | 2017-11-13 → 2017-11-20 (+7d) |  | 0.38d → 0d |  | resources Mover → none |
| 23 | Assemble new furniture | 2017-11-14 → 2017-11-20 (+6d) | 2017-11-15 → 2017-11-22 (+7d) |  |  | 22, 16 → 22 | resources Mover; Space Planner → none |
| 24 | Return equipment | 2017-11-15 → 2017-11-22 (+7d) | 2017-11-16 → 2017-11-23 (+7d) |  | 0.5d → 0d | 23FS-0.5d → 23 | resources Mover; Operations Manager → none |
| 25 | Unpack workspace | 2017-11-16 → 2017-11-23 (+7d) | 2017-11-20 → 2017-11-24 (+4d) | 2d → 1d | 0.5d → 0d |  | resources Mover; Administrative Assistant → none |
| 26 | Workspace final clean | 2017-11-20 → 2017-11-24 (+4d) | 2017-11-21 → 2017-11-27 (+6d) |  | 0.5d → 0d |  | resources Janitor [50%]; Mover [50%] → none |
| 27 | Workspace remodel complete | 2017-11-22 → 2017-11-27 (+5d) | 2017-11-22 → 2017-11-27 (+5d) |  |  | 26 → 18 | constraint must finish on 2017-11-22 → none |

## Version 10 (saved 2016-05-29, file 2link.mpp)

Last finish 2017-11-27 → 2017-10-20 (-38d).

Changed:

| ID | Task | Start | Finish | Duration | Total float | Predecessors |
| --- | --- | --- | --- | --- | --- | --- |
| 1 | **Office Workspace Remodel** |  | 2017-11-27 → 2017-10-20 (-38d) | 35.5d → 10d |  |  |
| 2 | **Space planning** |  | 2017-10-24 → 2017-10-13 (-11d) | 12d → 5d | 0d → 5d |  |
| 4 | Hire space planner | 2017-10-16 → 2017-10-09 (-7d) | 2017-10-17 → 2017-10-10 (-7d) |  | 0d → 8d | 3 → none |
| 5 | Meeting with space planner | 2017-10-18 → 2017-10-09 (-9d) | 2017-10-19 → 2017-10-10 (-9d) |  | 0d → 8d | 4 → none |
| 6 | Finalize space plan | 2017-10-20 → 2017-10-09 (-11d) | 2017-10-24 → 2017-10-11 (-13d) |  | 0d → 7d | 5 → none |
| 7 | Space plan complete | 2017-10-24 → 2017-10-09 (-15d) | 2017-10-24 → 2017-10-09 (-15d) |  | 0d → 10d | 6 → none |
| 8 | **Furniture selection** | 2017-10-20 → 2017-10-09 (-11d) | 2017-11-06 → 2017-10-18 (-19d) | 12d → 7.5d | 14.5d → 2.5d |  |
| 9 | Preview furniture selections | 2017-10-20 → 2017-10-09 (-11d) | 2017-10-23 → 2017-10-10 (-13d) |  | 14.5d → 8d | 5 → none |
| 10 | Select new furniture | 2017-10-24 → 2017-10-09 (-15d) | 2017-10-25 → 2017-10-10 (-15d) |  | 14.5d → 8d | 9 → none |
| 11 | Order new furniture | 2017-10-26 → 2017-10-09 (-17d) | 2017-10-26 → 2017-10-09 (-17d) |  | 14.5d → 9.5d | 10 → none |
| 12 | Delivery time | 2017-10-26 → 2017-10-09 (-17d) | 2017-11-06 → 2017-10-18 (-19d) |  | 14.5d → 2.5d | 11 → none |
| 13 | Furniture delivered | 2017-11-06 → 2017-10-09 (-28d) | 2017-11-06 → 2017-10-09 (-28d) |  | 14.5d → 10d | 12 → none |
| 14 | **Remodel workspace** | 2017-10-25 → 2017-10-09 (-16d) | 2017-11-13 → 2017-10-20 (-24d) | 14d → 10d |  |  |
| 15 | Hire contractor | 2017-10-25 → 2017-10-09 (-16d) | 2017-10-30 → 2017-10-12 (-18d) |  | 0d → 6d | 7 → none |
| 16 | Remodel workspace | 2017-10-31 → 2017-10-09 (-22d) | 2017-11-13 → 2017-10-20 (-24d) |  |  | 15 → none |
| 17 | Remodel complete | 2017-11-13 → 2017-10-09 (-35d) | 2017-11-13 → 2017-10-09 (-35d) |  | 0d → 10d | 16 → none |
| 18 | **New workspace** | 2017-11-14 → 2017-10-09 (-36d) | 2017-11-27 → 2017-10-10 (-48d) | 9.5d → 2d | 0d → 8d | 14 → none |
| 19 | Hire mover | 2017-11-14 → 2017-10-09 (-36d) | 2017-11-15 → 2017-10-10 (-36d) |  | 0d → 8d |  |
| 20 | Pack workspace | 2017-11-16 → 2017-10-09 (-38d) | 2017-11-16 → 2017-10-09 (-38d) |  | 0d → 9d | 19 → none |
| 21 | Move equipment | 2017-11-17 → 2017-10-09 (-39d) | 2017-11-17 → 2017-10-09 (-39d) |  | 0d → 9.5d | 20 → none |
| 22 | Remove existing furniture | 2017-11-17 → 2017-10-09 (-39d) | 2017-11-20 → 2017-10-09 (-42d) |  | 0d → 9d | 21 → none |
| 23 | Assemble new furniture | 2017-11-20 → 2017-10-09 (-42d) | 2017-11-22 → 2017-10-10 (-43d) |  | 0d → 8d | 22 → none |
| 24 | Return equipment | 2017-11-22 → 2017-10-09 (-44d) | 2017-11-23 → 2017-10-09 (-45d) |  | 0d → 9d | 23 → none |
| 25 | Unpack workspace | 2017-11-23 → 2017-10-09 (-45d) | 2017-11-24 → 2017-10-09 (-46d) |  | 0d → 9d | 24 → none |
| 26 | Workspace final clean | 2017-11-24 → 2017-10-09 (-46d) | 2017-11-27 → 2017-10-09 (-49d) |  | 0d → 9d | 25 → none |
| 27 | Workspace remodel complete | 2017-11-27 → 2017-10-09 (-49d) | 2017-11-27 → 2017-10-09 (-49d) |  | 0d → 10d | 18 → none |

## Version 11 (saved 2016-05-29, file 6locating.mpp)

Last finish 2017-10-20 → 2017-11-22 (+33d).

Changed:

| ID | Task | Start | Finish | Duration | Total float | Predecessors | Other |
| --- | --- | --- | --- | --- | --- | --- | --- |
| 1 | **Office Workspace Remodel** |  | 2017-10-20 → 2017-11-22 (+33d) | 10d → 32d |  |  |  |
| 2 | **Space planning** |  | 2017-10-13 → 2017-10-24 (+11d) | 5d → 12d | 5d → 0.88d |  |  |
| 3 | Interview space planners |  |  |  | 5d → 0.88d |  | resources none → Operations Manager; Office Manager; President [25%] |
| 4 | Hire space planner | 2017-10-09 → 2017-10-16 (+7d) | 2017-10-10 → 2017-10-17 (+7d) |  | 8d → 0.88d | none → 3 | resources none → President; Administrative Assistant |
| 5 | Meeting with space planner | 2017-10-09 → 2017-10-18 (+9d) | 2017-10-10 → 2017-10-19 (+9d) |  | 8d → 0.88d | none → 4 | resources none → President; Office Manager; Administrative Assistant; Operations Manager; Space Planner |
| 6 | Finalize space plan | 2017-10-09 → 2017-10-20 (+11d) | 2017-10-11 → 2017-10-24 (+13d) |  | 7d → 0.88d | none → 5 | resources none → Space Planner |
| 7 | Space plan complete | 2017-10-09 → 2017-10-24 (+15d) | 2017-10-09 → 2017-10-24 (+15d) |  | 10d → 0.88d | none → 6 |  |
| 8 | **Furniture selection** | 2017-10-09 → 2017-10-19 (+10d) | 2017-10-18 → 2017-11-02 (+15d) | 7.5d → 11d | 2.5d → 13d |  |  |
| 9 | Preview furniture selections | 2017-10-09 → 2017-10-19 (+10d) | 2017-10-10 → 2017-10-20 (+10d) |  | 8d → 13d | none → 5SS+1d | resources none → Office Manager; Operations Manager; Administrative Assistant |
| 10 | Select new furniture | 2017-10-09 → 2017-10-23 (+14d) | 2017-10-10 → 2017-10-23 (+13d) | 2d → 1d | 8d → 13d | none → 9 | resources none → Office Manager; Operations Manager |
| 11 | Order new furniture | 2017-10-09 → 2017-10-24 (+15d) | 2017-10-09 → 2017-10-24 (+15d) |  | 9.5d → 13d | none → 10 | resources none → Administrative Assistant |
| 12 | Delivery time | 2017-10-09 → 2017-10-24 (+15d) | 2017-10-18 → 2017-11-02 (+15d) |  | 2.5d → 13d | none → 11 | constraint none → finish no earlier than 2013-11-03; resources none → Administrative Assistant [10%] |
| 13 | Furniture delivered | 2017-10-09 → 2017-11-02 (+24d) | 2017-10-09 → 2017-11-02 (+24d) |  | 10d → 13d | none → 12 |  |
| 14 | **Remodel workspace** | 2017-10-09 → 2017-10-25 (+16d) | 2017-10-20 → 2017-11-06 (+17d) | 10d → 9d | 0d → 0.88d |  |  |
| 15 | Hire contractor | 2017-10-09 → 2017-10-25 (+16d) | 2017-10-12 → 2017-10-30 (+18d) |  | 6d → 0.88d | none → 7 | resources none → President; Operations Manager |
| 16 | Remodel workspace | 2017-10-09 → 2017-10-31 (+22d) | 2017-10-20 → 2017-11-06 (+17d) | 2w → 1w | 0d → 0.88d | none → 15 | resources none → Contractor [200%] |
| 17 | Remodel complete | 2017-10-09 → 2017-11-06 (+28d) | 2017-10-09 → 2017-11-06 (+28d) |  | 10d → 0.88d | none → 16 |  |
| 18 | **New workspace** | 2017-10-09 → 2017-11-07 (+29d) | 2017-10-10 → 2017-11-21 (+42d) | 2d → 10.5d | 8d → 0.5d | none → 14 |  |
| 19 | Hire mover | 2017-10-09 → 2017-11-07 (+29d) | 2017-10-10 → 2017-11-08 (+29d) |  | 8d → 0.88d | none → 15SS | resources none → Office Manager; Operations Manager |
| 20 | Pack workspace | 2017-10-09 → 2017-11-09 (+31d) | 2017-10-09 → 2017-11-09 (+31d) |  | 9d → 0.88d | none → 19, 15 | resources none → Operations Manager; Mover |
| 21 | Move Equipment | 2017-10-09 → 2017-11-09 (+31d) | 2017-10-09 → 2017-11-09 (+31d) |  | 9.5d → 0.88d | none → 20FF | was named Move equipment; resources none → Mover; Operations Manager |
| 22 | Remove existing furniture | 2017-10-09 → 2017-11-09 (+31d) | 2017-10-09 → 2017-11-13 (+35d) |  | 9d → 0.38d | none → 21 | resources none → Mover |
| 23 | Assemble new furniture | 2017-10-09 → 2017-11-14 (+36d) | 2017-10-10 → 2017-11-15 (+36d) |  | 8d → 0d | none → 22, 16 | resources none → Mover; Space Planner [125%] |
| 24 | Return equipment | 2017-10-09 → 2017-11-15 (+37d) | 2017-10-09 → 2017-11-16 (+38d) |  | 9d → 0.5d | none → 23FS-0.5d | resources none → Mover; Operations Manager |
| 25 | Unpack workspace | 2017-10-09 → 2017-11-16 (+38d) | 2017-10-09 → 2017-11-20 (+42d) | 1d → 2d | 9d → 0.5d | none → 24 | resources none → Mover; Administrative Assistant |
| 26 | Workspace final clean | 2017-10-09 → 2017-11-20 (+42d) | 2017-10-09 → 2017-11-21 (+43d) |  | 9d → 0.5d | none → 25 | resources none → Janitor [50%]; Mover [50%] |
| 27 | Workspace remodel complete | 2017-10-09 → 2017-11-22 (+44d) | 2017-10-09 → 2017-11-22 (+44d) |  | 10d → 0d | none → 26 | constraint none → must finish on 2017-11-22 |

## Version 12 (saved 2016-05-29, file 6resolving.mpp)

Last finish stays 2017-11-22.

Changed:

| ID | Task | Other |
| --- | --- | --- |
| 21 | Move Equipment | resources Mover; Operations Manager → Mover; Office Manager |

## Version 13 (saved 2016-05-30, file 6baseline.mpp)

Last finish stays 2017-11-22.

Changed:

| ID | Task | Start | Finish | Duration | Total float | Other |
| --- | --- | --- | --- | --- | --- | --- |
| 8 | **Furniture selection** | 2017-10-19 → 2017-10-20 (+1d) | 2017-11-02 → 2017-11-06 (+4d) | 11d → 12d | 13d → 11d |  |
| 9 | Preview furniture selections | 2017-10-19 → 2017-10-20 (+1d) | 2017-10-20 → 2017-10-24 (+4d) | 2d → 3d | 13d → 11d | resources Office Manager; Operations Manager; Administrative Assistant → Office Manager; Administrative Assistant |
| 10 | Select new furniture | 2017-10-23 → 2017-10-25 (+2d) | 2017-10-23 → 2017-10-25 (+2d) |  | 13d → 11d | resources Office Manager; Operations Manager → Office Manager |
| 11 | Order new furniture | 2017-10-24 → 2017-10-26 (+2d) | 2017-10-24 → 2017-10-26 (+2d) |  | 13d → 11d |  |
| 12 | Delivery time | 2017-10-24 → 2017-10-26 (+2d) | 2017-11-02 → 2017-11-06 (+4d) |  | 13d → 11d |  |
| 13 | Furniture delivered | 2017-11-02 → 2017-11-06 (+4d) | 2017-11-02 → 2017-11-06 (+4d) |  | 13d → 11d |  |
| 20 | Pack workspace |  |  |  | 0.88d → 0d | resources Operations Manager; Mover → Operations Manager; Janitor |
| 23 | Assemble new furniture |  |  |  |  | resources Mover; Space Planner [125%] → Office Manager; Space Planner [125%] |

## Version 14 (saved 2016-05-30, file 7update.mpp)

Last finish stays 2017-11-22.

Changed:

| ID | Task | Start | Finish | Total float | Other |
| --- | --- | --- | --- | --- | --- |
| 1 | **Office Workspace Remodel** |  |  |  | baseline start none → 2013-10-07; baseline finish none → 2013-11-20 |
| 2 | **Space planning** |  |  |  | baseline start none → 2013-10-07; baseline finish none → 2013-10-22 |
| 3 | Interview space planners |  |  |  | baseline start none → 2013-10-07; baseline finish none → 2013-10-11 |
| 4 | Hire space planner |  |  |  | baseline start none → 2013-10-14; baseline finish none → 2013-10-15 |
| 5 | Meeting with space planner |  |  |  | baseline start none → 2013-10-16; baseline finish none → 2013-10-17 |
| 6 | Finalize space plan |  |  |  | baseline start none → 2013-10-18; baseline finish none → 2013-10-22 |
| 7 | Space plan complete |  |  |  | baseline start none → 2013-10-22; baseline finish none → 2013-10-22 |
| 8 | **Furniture selection** | 2017-10-20 → 2017-10-23 (+3d) | 2017-11-06 → 2017-11-07 (+1d) | 11d → 10d | baseline start none → 2013-10-21; baseline finish none → 2013-11-05 |
| 9 | Preview furniture selections | 2017-10-20 → 2017-10-23 (+3d) | 2017-10-24 → 2017-10-25 (+1d) | 11d → 10d | baseline start none → 2013-10-21; baseline finish none → 2013-10-23 |
| 10 | Select new furniture | 2017-10-25 → 2017-10-26 (+1d) | 2017-10-25 → 2017-10-26 (+1d) | 11d → 10d | baseline start none → 2013-10-24; baseline finish none → 2013-10-24 |
| 11 | Order new furniture | 2017-10-26 → 2017-10-27 (+1d) | 2017-10-26 → 2017-10-27 (+1d) | 11d → 10d | baseline start none → 2013-10-25; baseline finish none → 2013-10-25 |
| 12 | Delivery time | 2017-10-26 → 2017-10-27 (+1d) | 2017-11-06 → 2017-11-07 (+1d) | 11d → 10d | baseline start none → 2013-10-25; baseline finish none → 2013-11-05 |
| 13 | Furniture delivered | 2017-11-06 → 2017-11-07 (+1d) | 2017-11-06 → 2017-11-07 (+1d) | 11d → 10d | baseline start none → 2013-11-05; baseline finish none → 2013-11-05 |
| 14 | **Remodel workspace** |  |  |  | baseline start none → 2013-10-23; baseline finish none → 2013-11-04 |
| 15 | Hire contractor |  |  |  | baseline start none → 2013-10-23; baseline finish none → 2013-10-28 |
| 16 | Remodel workspace |  |  |  | baseline start none → 2013-10-29; baseline finish none → 2013-11-04 |
| 17 | Remodel complete |  |  |  | baseline start none → 2013-11-04; baseline finish none → 2013-11-04 |
| 18 | **New workspace** |  |  |  | baseline start none → 2013-11-05; baseline finish none → 2013-11-19 |
| 19 | Hire mover |  |  |  | baseline start none → 2013-11-05; baseline finish none → 2013-11-06 |
| 20 | Pack workspace |  |  |  | baseline start none → 2013-11-07; baseline finish none → 2013-11-07 |
| 21 | Move Equipment |  |  |  | baseline start none → 2013-11-07; baseline finish none → 2013-11-07 |
| 22 | Remove existing furniture |  |  |  | baseline start none → 2013-11-07; baseline finish none → 2013-11-11 |
| 23 | Assemble new furniture |  |  |  | baseline start none → 2013-11-12; baseline finish none → 2013-11-13 |
| 24 | Return equipment |  |  |  | baseline start none → 2013-11-13; baseline finish none → 2013-11-14 |
| 25 | Unpack workspace |  |  |  | baseline start none → 2013-11-14; baseline finish none → 2013-11-18 |
| 26 | Workspace final clean |  |  |  | baseline start none → 2013-11-18; baseline finish none → 2013-11-19 |
| 27 | Workspace remodel complete |  |  |  | baseline start none → 2013-11-20; baseline finish none → 2013-11-20 |

## Version 15 (data date 2017-11-06, saved 2016-05-30, file 8filter.mpp)

Last finish 2017-11-22 → 2017-11-24 (+2d). Complete tasks 0 → 11.

Changed:

| ID | Task | Start | Finish | Duration | Complete | Total float | Other |
| --- | --- | --- | --- | --- | --- | --- | --- |
| 1 | **Office Workspace Remodel** | 2017-10-09 A | 2017-11-22 → 2017-11-24 (+2d) | 32d → 34d | 0% → 74% |  | baseline finish 2013-11-20 → 2013-11-22 |
| 2 | **Space planning** | 2017-10-09 A | 2017-10-24 → 2017-10-25 A (+1d) | 12d → 13d | 0% → 100% | 0d → none | baseline finish 2013-10-22 → 2013-10-23 |
| 3 | Interview space planners | 2017-10-09 A | 2017-10-13 A |  | 0% → 100% | 0d → none |  |
| 4 | Hire space planner | 2017-10-16 A | 2017-10-17 A |  | 0% → 100% | 0d → none |  |
| 5 | Meeting with space planner | 2017-10-18 A | 2017-10-19 A |  | 0% → 100% | 0d → none |  |
| 6 | Finalize space plan | 2017-10-20 → 2017-10-23 A (+3d) | 2017-10-24 → 2017-10-25 A (+1d) |  | 0% → 100% | 0d → none | baseline start 2013-10-18 → 2013-10-21; baseline finish 2013-10-22 → 2013-10-23 |
| 7 | Space plan complete | 2017-10-24 → 2017-10-25 A (+1d) | 2017-10-24 → 2017-10-25 A (+1d) |  | 0% → 100% | 0d → none | baseline start 2013-10-22 → 2013-10-23; baseline finish 2013-10-22 → 2013-10-23 |
| 8 | **Furniture selection** | 2017-10-23 → 2017-10-24 A (+1d) | 2017-11-07 → 2017-11-09 (+2d) | 12d → 13d | 0% → 79% |  | baseline start 2013-10-21 → 2013-10-22; baseline finish 2013-11-05 → 2013-11-07 |
| 9 | Preview furniture selections | 2017-10-23 → 2017-10-24 A (+1d) | 2017-10-25 → 2017-10-26 A (+1d) |  | 0% → 100% | 10d → none | baseline start 2013-10-21 → 2013-10-22; baseline finish 2013-10-23 → 2013-10-24 |
| 10 | Select new furniture | 2017-10-26 → 2017-10-30 A (+4d) | 2017-10-26 → 2017-11-01 A (+6d) | 1d → 3d | 0% → 100% | 10d → none | baseline start 2013-10-24 → 2013-10-28; baseline finish 2013-10-24 → 2013-10-29 |
| 11 | Order new furniture | 2017-10-27 → 2017-10-31 A (+4d) | 2017-10-27 → 2017-10-31 A (+4d) |  | 0% → 100% | 10d → none | baseline start 2013-10-25 → 2013-10-29; baseline finish 2013-10-25 → 2013-10-29 |
| 12 | Delivery time | 2017-10-27 → 2017-10-31 A (+4d) | 2017-11-07 → 2017-11-09 (+2d) |  | 0% → 60% |  | baseline start 2013-10-25 → 2013-10-29; baseline finish 2013-11-05 → 2013-11-07 |
| 13 | Furniture delivered | 2017-11-07 → 2017-11-09 (+2d) | 2017-11-07 → 2017-11-09 (+2d) |  |  |  | baseline start 2013-11-05 → 2013-11-07; baseline finish 2013-11-05 → 2013-11-07 |
| 14 | **Remodel workspace** | 2017-10-25 A | 2017-11-06 → 2017-11-07 A (+1d) |  | 0% → 100% | 0d → none | baseline finish 2013-11-04 → 2013-11-05 |
| 15 | Hire contractor | 2017-10-25 A | 2017-10-30 A |  | 0% → 100% | 0d → none |  |
| 16 | Remodel workspace | 2017-10-31 A | 2017-11-06 A |  | 0% → 100% | 0d → none |  |
| 17 | Remodel complete | 2017-11-06 → 2017-11-07 A (+1d) | 2017-11-06 → 2017-11-07 A (+1d) |  | 0% → 100% | 0d → none | baseline start 2013-11-04 → 2013-11-05; baseline finish 2013-11-04 → 2013-11-05 |
| 18 | **New workspace** | 2017-11-07 A | 2017-11-21 → 2017-11-23 (+2d) | 10.5d → 12.5d | 0% → 17% | 0d → 0.5d | baseline finish 2013-11-19 → 2013-11-21 |
| 19 | Hire mover | 2017-11-07 A |  |  | 0% → 75% | 0d → 2.33d |  |
| 20 | Pack workspace | 2017-11-09 → 2017-11-13 A (+4d) | 2017-11-09 → 2017-11-14 (+5d) | 1d → 1.5d | 0% → 22% | 0d → -1.62d | baseline start 2013-11-07 → 2013-11-11; baseline finish 2013-11-07 → 2013-11-12 |
| 21 | Move Equipment | 2017-11-09 → 2017-11-14 (+5d) | 2017-11-09 → 2017-11-14 (+5d) |  |  | 0.88d → -1.62d | baseline start 2013-11-07 → 2013-11-12; baseline finish 2013-11-07 → 2013-11-12 |
| 22 | Remove existing furniture | 2017-11-09 → 2017-11-14 (+5d) | 2017-11-13 → 2017-11-15 (+2d) |  |  | 0.38d → -1d | baseline start 2013-11-07 → 2013-11-12; baseline finish 2013-11-11 → 2013-11-13 |
| 23 | Assemble new furniture | 2017-11-14 → 2017-11-16 (+2d) | 2017-11-15 → 2017-11-17 (+2d) |  |  | 0d → -2d | baseline start 2013-11-12 → 2013-11-14; baseline finish 2013-11-13 → 2013-11-15 |
| 24 | Return equipment | 2017-11-15 → 2017-11-17 (+2d) | 2017-11-16 → 2017-11-20 (+4d) |  |  |  | baseline start 2013-11-13 → 2013-11-15; baseline finish 2013-11-14 → 2013-11-18 |
| 25 | Unpack workspace | 2017-11-16 → 2017-11-20 (+4d) | 2017-11-20 → 2017-11-22 (+2d) |  |  |  | baseline start 2013-11-14 → 2013-11-18; baseline finish 2013-11-18 → 2013-11-20 |
| 26 | Workspace final clean | 2017-11-20 → 2017-11-22 (+2d) | 2017-11-21 → 2017-11-23 (+2d) |  |  |  | baseline start 2013-11-18 → 2013-11-20; baseline finish 2013-11-19 → 2013-11-21 |
| 27 | Workspace remodel complete | 2017-11-22 → 2017-11-24 (+2d) | 2017-11-22 → 2017-11-24 (+2d) |  |  |  | constraint must finish on 2017-11-22 → must finish on 2017-11-24; baseline start 2013-11-20 → 2013-11-22; baseline finish 2013-11-20 → 2013-11-22 |

## Version 16 (saved 2016-05-31, file 3costs.mpp)

Last finish 2017-11-24 → 2017-11-28 (+4d). Complete tasks 11 → 0.

Changed:

| ID | Task | Start | Finish | Duration | Complete | Total float | Predecessors | Other |
| --- | --- | --- | --- | --- | --- | --- | --- | --- |
| 1 | **Office Workspace Remodel** | 2017-10-09 A → 2017-10-09 | 2017-11-24 → 2017-11-28 (+4d) | 34d → 36.5d | 74% → 0% |  |  | baseline start 2013-10-07 → none; baseline finish 2013-11-22 → none |
| 2 | **Space planning** | 2017-10-09 A → 2017-10-09 | 2017-10-25 A → 2017-10-24 (-1d) | 13d → 12d | 100% → 0% | none → 0d |  | baseline start 2013-10-07 → none; baseline finish 2013-10-23 → none |
| 3 | Interview space planners | 2017-10-09 A → 2017-10-09 | 2017-10-13 A → 2017-10-13 |  | 100% → 0% | none → 0d |  | resources Operations Manager; Office Manager; President [25%] → Administrative Assistant; Mover; Contractor; baseline start 2013-10-07 → none; baseline finish 2013-10-11 → none |
| 4 | Hire space planner | 2017-10-16 A → 2017-10-16 | 2017-10-17 A → 2017-10-17 |  | 100% → 0% | none → 0d |  | resources President; Administrative Assistant → Administrative Assistant; Janitor; baseline start 2013-10-14 → none; baseline finish 2013-10-15 → none |
| 5 | Meeting with space planner | 2017-10-18 A → 2017-10-18 | 2017-10-19 A → 2017-10-19 |  | 100% → 0% | none → 0d |  | resources President; Office Manager; Administrative Assistant; Operations Manager; Space Planner → Administrative Assistant; Contractor; Janitor; Mover; Office Manager; baseline start 2013-10-16 → none; baseline finish 2013-10-17 → none |
| 6 | Finalize space plan | 2017-10-23 A → 2017-10-20 (-3d) | 2017-10-25 A → 2017-10-24 (-1d) |  | 100% → 0% | none → 0.88d |  | resources Space Planner → Office Manager; baseline start 2013-10-21 → none; baseline finish 2013-10-23 → none |
| 7 | Space plan complete | 2017-10-25 A → 2017-10-24 (-1d) | 2017-10-25 A → 2017-10-24 (-1d) |  | 100% → 0% | none → 0.88d |  | baseline start 2013-10-23 → none; baseline finish 2013-10-23 → none |
| 8 | **Furniture selection** | 2017-10-24 A → 2017-10-19 (-5d) | 2017-11-09 → 2017-11-08 (-1d) | 13d → 15d | 79% → 0% | 10d → 13.5d |  | baseline start 2013-10-22 → none; baseline finish 2013-11-07 → none |
| 9 | Preview furniture selections | 2017-10-24 A → 2017-10-19 (-5d) | 2017-10-26 A → 2017-10-23 (-3d) |  | 100% → 0% | none → 13.5d |  | resources Office Manager; Administrative Assistant → Contractor; Mover; Janitor; baseline start 2013-10-22 → none; baseline finish 2013-10-24 → none |
| 10 | Select new furniture | 2017-10-30 A → 2017-10-24 (-6d) | 2017-11-01 A → 2017-10-25 (-7d) | 3d → 2d | 100% → 0% | none → 13.5d |  | resources Office Manager → Contractor; Mover; baseline start 2013-10-28 → none; baseline finish 2013-10-29 → none |
| 11 | Order new furniture | 2017-10-31 A → 2017-10-26 (-5d) | 2017-10-31 A → 2017-10-26 (-5d) |  | 100% → 0% | none → 13.5d |  | resources Administrative Assistant → Janitor; baseline start 2013-10-29 → none; baseline finish 2013-10-29 → none |
| 12 | Delivery time | 2017-10-31 A → 2017-10-26 (-5d) | 2017-11-09 → 2017-11-08 (-1d) |  | 60% → 0% | 10d → 13.5d |  | constraint finish no earlier than 2013-11-03 → none; resources Administrative Assistant [10%] → Janitor [10%]; baseline start 2013-10-29 → none; baseline finish 2013-11-07 → none |
| 13 | Furniture delivered | 2017-11-09 → 2017-11-08 (-1d) | 2017-11-09 → 2017-11-08 (-1d) |  |  | 10d → 13.5d |  | baseline start 2013-11-07 → none; baseline finish 2013-11-07 → none |
| 14 | **Remodel workspace** | 2017-10-25 A → 2017-10-25 | 2017-11-07 A → 2017-11-13 (+6d) | 9d → 14d | 100% → 0% | none → 0.88d |  | baseline start 2013-10-23 → none; baseline finish 2013-11-05 → none |
| 15 | Hire contractor | 2017-10-25 A → 2017-10-25 | 2017-10-30 A → 2017-10-30 |  | 100% → 0% | none → 0.88d |  | resources President; Operations Manager → Administrative Assistant; Mover; baseline start 2013-10-23 → none; baseline finish 2013-10-28 → none |
| 16 | Remodel workspace | 2017-10-31 A → 2017-10-31 | 2017-11-06 A → 2017-11-13 (+7d) | 1w → 2w | 100% → 0% | none → 0.88d |  | resources Contractor [200%] → Space Planner; baseline start 2013-10-29 → none; baseline finish 2013-11-04 → none |
| 17 | Remodel complete | 2017-11-07 A → 2017-11-13 (+6d) | 2017-11-07 A → 2017-11-13 (+6d) |  | 100% → 0% | none → 0.88d |  | baseline start 2013-11-05 → none; baseline finish 2013-11-05 → none |
| 18 | **New workspace** | 2017-11-07 A → 2017-11-14 (+7d) | 2017-11-23 → 2017-11-28 (+5d) | 12.5d → 10.5d | 17% → 0% | 0.5d → 0d |  | baseline start 2013-11-05 → none; baseline finish 2013-11-21 → none |
| 19 | Hire mover | 2017-11-07 A → 2017-11-14 (+7d) | 2017-11-08 → 2017-11-15 (+7d) |  | 75% → 0% | 2.33d → 0.88d | 15SS → none | resources Office Manager; Operations Manager → Contractor; Mover; baseline start 2013-11-05 → none; baseline finish 2013-11-06 → none |
| 20 | Pack workspace | 2017-11-13 A → 2017-11-16 (+3d) | 2017-11-14 → 2017-11-16 (+2d) | 1.5d → 1d | 22% → 0% | -1.62d → 0.88d | 19, 15 → 19 | resources Operations Manager; Janitor → Mover; President; baseline start 2013-11-11 → none; baseline finish 2013-11-12 → none |
| 21 | Move Equipment | 2017-11-14 → 2017-11-16 (+2d) | 2017-11-14 → 2017-11-16 (+2d) |  |  | -1.62d → 0.88d |  | resources Mover; Office Manager → President; Mover; baseline start 2013-11-12 → none; baseline finish 2013-11-12 → none |
| 22 | Remove existing furniture | 2017-11-14 → 2017-11-16 (+2d) | 2017-11-15 → 2017-11-20 (+5d) |  |  | -1d → 0.38d |  | resources Mover → President; baseline start 2013-11-12 → none; baseline finish 2013-11-13 → none |
| 23 | Assemble new furniture | 2017-11-16 → 2017-11-21 (+5d) | 2017-11-17 → 2017-11-22 (+5d) |  |  | -2d → 0d | 22, 16 → 22 | resources Office Manager; Space Planner [125%] → President; Office Manager; baseline start 2013-11-14 → none; baseline finish 2013-11-15 → none |
| 24 | Return equipment | 2017-11-17 → 2017-11-22 (+5d) | 2017-11-20 → 2017-11-23 (+3d) |  |  | 0.5d → 0d |  | resources Mover; Operations Manager → President; Mover; baseline start 2013-11-15 → none; baseline finish 2013-11-18 → none |
| 25 | Unpack workspace | 2017-11-20 → 2017-11-23 (+3d) | 2017-11-22 → 2017-11-27 (+5d) | 2d → 1.5d |  | 0.5d → 0d |  | resources Mover; Administrative Assistant → President; Janitor; baseline start 2013-11-18 → none; baseline finish 2013-11-20 → none |
| 26 | Workspace final clean | 2017-11-22 → 2017-11-27 (+5d) | 2017-11-23 → 2017-11-28 (+5d) |  |  | 0.5d → 0d |  | resources Janitor [50%]; Mover [50%] → Janitor; baseline start 2013-11-20 → none; baseline finish 2013-11-21 → none |
| 27 | Workspace remodel complete | 2017-11-24 → 2017-11-28 (+4d) | 2017-11-24 → 2017-11-28 (+4d) |  |  |  | 26 → 18 | constraint must finish on 2017-11-24 → none; baseline start 2013-11-22 → none; baseline finish 2013-11-22 → none |

## Version 17 (saved 2016-05-31, file 3projcal.mpp)

Last finish 2017-11-28 → 2017-11-24 (-4d).

Changed:

| ID | Task | Start | Finish | Duration | Total float | Other |
| --- | --- | --- | --- | --- | --- | --- |
| 1 | **Office Workspace Remodel** |  | 2017-11-28 → 2017-11-24 (-4d) | 36.5d → 34.5d |  |  |
| 3 | Interview space planners |  |  |  |  | resources Administrative Assistant; Mover; Contractor → President; Operations Manager; Office Manager |
| 4 | Hire space planner |  |  |  |  | resources Administrative Assistant; Janitor → President; Administrative Assistant |
| 5 | Meeting with space planner |  |  |  |  | resources Administrative Assistant; Contractor; Janitor; Mover; Office Manager → President; Office Manager; Administrative Assistant; Operations Manager; Space Planner |
| 6 | Finalize space plan |  |  |  | 0.88d → 0d | resources Office Manager → Space Planner |
| 8 | **Furniture selection** |  | 2017-11-08 → 2017-11-03 (-5d) | 15d → 12d | 13.5d → 14.5d |  |
| 9 | Preview furniture selections |  | 2017-10-23 → 2017-10-20 (-3d) | 3d → 2d | 13.5d → 14.5d | resources Contractor; Mover; Janitor → Office Manager; Operations Manager; Administrative Assistant |
| 10 | Select new furniture | 2017-10-24 → 2017-10-23 (-1d) | 2017-10-25 → 2017-10-24 (-1d) |  | 13.5d → 14.5d | resources Contractor; Mover → Office Manager; Operations Manager |
| 11 | Order new furniture | 2017-10-26 → 2017-10-25 (-1d) | 2017-10-26 → 2017-10-25 (-1d) |  | 13.5d → 14.5d | resources Janitor → Administrative Assistant |
| 12 | Delivery time | 2017-10-26 → 2017-10-25 (-1d) | 2017-11-08 → 2017-11-03 (-5d) |  | 13.5d → 14.5d | resources Janitor [10%] → Administrative Assistant [10%] |
| 13 | Furniture delivered | 2017-11-08 → 2017-11-03 (-5d) | 2017-11-08 → 2017-11-03 (-5d) |  | 13.5d → 14.5d |  |
| 15 | Hire contractor |  |  |  | 0.88d → 0d | resources Administrative Assistant; Mover → President; Operations Manager |
| 16 | Remodel workspace |  |  |  | 0.88d → 0d | resources Space Planner → Contractor |
| 18 | **New workspace** |  | 2017-11-28 → 2017-11-24 (-4d) | 10.5d → 8.5d |  |  |
| 19 | Hire mover |  |  |  | 0.88d → 0d | resources Contractor; Mover → Office Manager; Operations Manager |
| 20 | Pack workspace |  |  |  | 0.88d → 0d | resources Mover; President → Operations Manager; Mover |
| 21 | Move Equipment |  |  |  | 0.88d → 0d | resources President; Mover → Mover; Operations Manager |
| 22 | Remove existing furniture | 2017-11-16 → 2017-11-17 (+1d) | 2017-11-20 → 2017-11-17 (-3d) |  | 0.38d → 0d | resources President → Mover |
| 23 | Assemble new furniture | 2017-11-21 → 2017-11-20 (-1d) | 2017-11-22 → 2017-11-21 (-1d) |  |  | resources President; Office Manager → Mover; Space Planner |
| 24 | Return equipment | 2017-11-22 → 2017-11-21 (-1d) | 2017-11-23 → 2017-11-22 (-1d) |  |  | resources President; Mover → Mover; Operations Manager |
| 25 | Unpack workspace | 2017-11-23 → 2017-11-22 (-1d) | 2017-11-27 → 2017-11-23 (-4d) | 1.5d → 1d |  | resources President; Janitor → Mover; Administrative Assistant |
| 26 | Workspace final clean | 2017-11-27 → 2017-11-23 (-4d) | 2017-11-28 → 2017-11-24 (-4d) |  |  |  |
| 27 | Workspace remodel complete | 2017-11-28 → 2017-11-24 (-4d) | 2017-11-28 → 2017-11-24 (-4d) |  |  |  |

## Version 18 (saved 2016-05-31, file 3taskcal.mpp)

Last finish 2017-11-24 → 2017-11-27 (+3d).

Changed:

| ID | Task | Start | Finish | Duration |
| --- | --- | --- | --- | --- |
| 1 | **Office Workspace Remodel** |  | 2017-11-24 → 2017-11-27 (+3d) | 34.5d → 35.5d |
| 18 | **New workspace** |  | 2017-11-24 → 2017-11-27 (+3d) | 8.5d → 9.5d |
| 26 | Workspace final clean |  | 2017-11-24 → 2017-11-27 (+3d) |  |
| 27 | Workspace remodel complete | 2017-11-24 → 2017-11-27 (+3d) | 2017-11-24 → 2017-11-27 (+3d) |  |

## Version 19 (saved 2016-05-31, file 4print.mpp)

Last finish stays 2017-11-27.

Changed:

| ID | Task | Start | Finish | Duration | Total float | Other |
| --- | --- | --- | --- | --- | --- | --- |
| 1 | **Office Workspace Remodel** |  |  | 35.5d → 36d |  |  |
| 3 | Interview space planners |  |  |  | 0d → 0.88d | resources President; Operations Manager; Office Manager → president; operations manager; office manager |
| 4 | Hire space planner |  |  |  | 0d → 0.88d | resources President; Administrative Assistant → president; administrative assistant |
| 5 | Meeting with space planner |  |  |  | 0d → 0.88d | resources President; Office Manager; Administrative Assistant; Operations Manager; Space Planner → president; office manager; administrative assistant; operations manager; space planner |
| 6 | Finalize space plan |  |  |  | 0d → 0.88d | resources Space Planner → space planner |
| 9 | Preview furniture selections |  |  |  | 15.5d → 16d | resources Office Manager; Operations Manager; Administrative Assistant → office manager; operations manager; administrative assistant |
| 10 | Select new furniture |  |  |  | 15.5d → 16d | resources Office Manager; Operations Manager → office manager; operations manager |
| 11 | Order new furniture |  |  |  | 15.5d → 16d | resources Administrative Assistant → administrative assistant |
| 12 | Delivery time |  |  |  | 15.5d → 16d | resources Administrative Assistant [10%] → administrative assistant [10%] |
| 15 | Hire contractor |  |  |  | 0d → 0.88d | resources President; Operations Manager → president; operations manager |
| 16 | Remodel workspace |  |  |  | 0d → 0.88d | resources Contractor → contractor |
| 18 | **New workspace** |  |  | 9.5d → 10d |  |  |
| 19 | Hire mover |  |  |  | 0d → 0.88d | resources Office Manager; Operations Manager → office manager; operations manager |
| 20 | Pack workspace |  |  |  | 0d → 0.88d | resources Operations Manager; Mover → operations manager; mover |
| 21 | Move Equipment |  |  |  | 0d → 0.88d | resources Mover; Operations Manager → mover; operations manager |
| 22 | Remove existing furniture | 2017-11-17 → 2017-11-16 (-1d) | 2017-11-17 → 2017-11-20 (+3d) |  | 0d → 0.38d | resources Mover → mover |
| 23 | Assemble new furniture | 2017-11-20 → 2017-11-21 (+1d) | 2017-11-21 → 2017-11-22 (+1d) |  | 0d → 0.5d | resources Mover; Space Planner → mover; space planner |
| 24 | Return equipment | 2017-11-21 → 2017-11-22 (+1d) | 2017-11-22 → 2017-11-23 (+1d) |  | 0d → 0.5d | resources Mover; Operations Manager → mover; operations manager |
| 25 | Unpack workspace | 2017-11-22 → 2017-11-23 (+1d) | 2017-11-23 → 2017-11-24 (+1d) |  | 0d → 0.5d | resources Mover; Administrative Assistant → mover; administrative assistant |
| 26 | Workspace final clean | 2017-11-23 → 2017-11-27 (+4d) |  |  |  | resources Janitor → janitor |

## Version 20 (data date 2014-01-11, saved 2016-05-31, file 4report.mpp)

Last finish 2017-11-27 → 2017-11-15 (-12d). Complete tasks 0 → 15.

Changed:

| ID | Task | Start | Finish | Duration | Complete | Total float | Predecessors | Other |
| --- | --- | --- | --- | --- | --- | --- | --- | --- |
| 1 | **Office Workspace Remodel** | 2017-10-09 A | 2017-11-27 → 2017-11-15 (-12d) | 36d → 27d | 0% → 88% |  |  |  |
| 2 | **Space planning** | 2017-10-09 A | 2017-10-24 → 2017-10-25 A (+1d) | 12d → 13d | 0% → 100% | 0.88d → none |  |  |
| 3 | Interview space planners | 2017-10-09 A | 2017-10-13 A |  | 0% → 100% | 0.88d → none |  | resources president; operations manager; office manager → Operations Manager; Office Manager; President [25%] |
| 4 | Hire space planner | 2017-10-16 A | 2017-10-17 → 2017-10-16 A (-1d) | 2d → 1d | 0% → 100% | 0.88d → none |  | resources president; administrative assistant → President; Administrative Assistant |
| 5 | Meeting with space planner | 2017-10-18 → 2017-10-17 A (-1d) | 2017-10-19 A | 2d → 3d | 0% → 100% | 0.88d → none |  | resources president; office manager; administrative assistant; operations manager; space planner → President; Office Manager; Administrative Assistant; Operations Manager; Space Planner |
| 6 | Finalize space plan | 2017-10-20 → 2017-10-23 A (+3d) | 2017-10-24 → 2017-10-25 A (+1d) |  | 0% → 100% | 0.88d → none |  | resources space planner → Space Planner |
| 7 | Space plan complete | 2017-10-24 A | 2017-10-24 A |  | 0% → 100% | 0.88d → none |  |  |
| 8 | **Furniture selection** | 2017-10-19 → 2017-10-23 A (+4d) | 2017-11-03 → 2017-11-06 A (+3d) | 12d → 10.5d | 0% → 100% | 16d → none |  |  |
| 9 | Preview furniture selections | 2017-10-19 → 2017-10-23 A (+4d) | 2017-10-20 → 2017-10-24 A (+4d) |  | 0% → 100% | 16d → none |  | resources office manager; operations manager; administrative assistant → Office Manager; Operations Manager; Administrative Assistant |
| 10 | Select new furniture | 2017-10-23 → 2017-10-24 A (+1d) | 2017-10-24 → 2017-10-25 A (+1d) | 2d → 1.5d | 0% → 100% | 16d → none |  | resources office manager; operations manager → Office Manager; Operations Manager |
| 11 | Order new furniture | 2017-10-25 A | 2017-10-25 A |  | 0% → 100% | 16d → none |  | resources administrative assistant → Administrative Assistant |
| 12 | Delivery time | 2017-10-25 → 2017-10-26 A (+1d) | 2017-11-03 → 2017-11-06 A (+3d) |  | 0% → 100% | 16d → none |  | constraint none → finish no earlier than 2015-11-04; resources administrative assistant [10%] → Administrative Assistant [10%] |
| 13 | Furniture delivered | 2017-11-03 A | 2017-11-03 A |  | 0% → 100% | 16d → none |  |  |
| 14 | **Remodel workspace** | 2017-10-25 A | 2017-11-13 → 2017-11-07 (-6d) | 14d → 9d | 0% → 94% | 0.88d → 6d |  |  |
| 15 | Hire contractor | 2017-10-25 A | 2017-10-30 A |  | 0% → 100% | 0.88d → none |  | resources president; operations manager → President; Operations Manager |
| 16 | Remodel workspace | 2017-10-31 A | 2017-11-13 → 2017-11-06 (-7d) | 2w → 1w | 0% → 90% | 0.88d → 1.5d |  | resources contractor → Contractor [200%] |
| 17 | Remodel complete | 2017-11-13 → 2017-11-07 (-6d) | 2017-11-13 → 2017-11-07 (-6d) |  |  | 0.88d → 6d |  | constraint none → start no earlier than 2017-11-07 |
| 18 | **New workspace** | 2017-11-14 → 2017-10-25 A (-20d) | 2017-11-27 → 2017-11-14 (-13d) | 10d → 15d | 0% → 57% |  | 14 → none |  |
| 19 | Hire mover | 2017-11-14 → 2017-10-25 A (-20d) | 2017-11-15 → 2017-10-30 A (-16d) | 2d → 4d | 0% → 100% | 0.88d → none | none → 15SS | resources office manager; operations manager → Office Manager |
| 20 | Pack workspace | 2017-11-16 → 2017-10-31 A (-16d) | 2017-11-16 → 2017-10-31 A (-16d) |  | 0% → 100% | 0.88d → none | 19 → 19, 15 | resources operations manager; mover → President; Janitor |
| 21 | Move Equipment | 2017-11-16 → 2017-10-31 A (-16d) | 2017-11-16 → 2017-10-31 A (-16d) |  | 0% → 100% | 0.88d → none |  | resources mover; operations manager → Mover; Operations Manager |
| 22 | Remove existing furniture | 2017-11-16 → 2017-11-01 A (-15d) | 2017-11-20 → 2017-11-01 A (-19d) |  | 0% → 100% | 0.38d → none |  | resources mover → Mover |
| 23 | Assemble new furniture | 2017-11-21 → 2017-11-07 (-14d) | 2017-11-22 → 2017-11-08 (-14d) |  |  | 0.5d → 1.5d | 22 → 22, 16 | resources mover; space planner → Office Manager; Space Planner [116.7%] |
| 24 | Return equipment | 2017-11-22 → 2017-11-08 (-14d) | 2017-11-23 → 2017-11-09 (-14d) |  |  | 0.5d → 1.5d |  | resources mover; operations manager → Mover; Operations Manager |
| 25 | Unpack workspace | 2017-11-23 → 2017-11-13 (-10d) | 2017-11-24 → 2017-11-13 (-11d) |  |  | 0.5d → 0d |  | constraint none → start no earlier than 2017-11-11; resources mover; administrative assistant → Mover; Administrative Assistant |
| 26 | Workspace final clean | 2017-11-27 → 2017-11-14 (-13d) | 2017-11-27 → 2017-11-14 (-13d) |  |  |  |  | constraint none → start no earlier than 2017-11-11; resources janitor → Janitor [50%]; Mover [50%] |
| 27 | Workspace remodel complete | 2017-11-27 → 2017-11-15 (-12d) | 2017-11-27 → 2017-11-15 (-12d) |  |  |  |  | constraint none → start no earlier than 2017-11-15 |

## Version 21 (data date 2017-11-06, saved 2017-10-31, file 7compare.mpp)

Last finish 2017-11-15 → 2017-11-24 (+9d). Complete tasks 15 → 11.

Changed:

| ID | Task | Start | Finish | Duration | Complete | Total float | Predecessors | Other |
| --- | --- | --- | --- | --- | --- | --- | --- | --- |
| 1 | **Office Workspace Remodel** |  | 2017-11-15 → 2017-11-24 (+9d) | 27d → 34d | 88% → 74% |  |  | baseline start none → 2017-10-09; baseline finish none → 2017-11-24 |
| 2 | **Space planning** |  |  |  |  |  |  | baseline start none → 2017-10-09; baseline finish none → 2017-10-25 |
| 3 | Interview space planners |  |  |  |  |  |  | baseline start none → 2017-10-09; baseline finish none → 2017-10-13 |
| 4 | Hire space planner |  | 2017-10-16 A → 2017-10-17 A (+1d) | 1d → 2d |  |  |  | baseline start none → 2017-10-16; baseline finish none → 2017-10-17 |
| 5 | Meeting with space planner | 2017-10-17 A → 2017-10-18 A (+1d) |  | 3d → 2d |  |  |  | baseline start none → 2017-10-18; baseline finish none → 2017-10-19 |
| 6 | Finalize space plan |  |  |  |  |  |  | baseline start none → 2017-10-23; baseline finish none → 2017-10-25 |
| 7 | Space plan complete | 2017-10-24 A → 2017-10-25 A (+1d) | 2017-10-24 A → 2017-10-25 A (+1d) |  |  |  |  | baseline start none → 2017-10-25; baseline finish none → 2017-10-25 |
| 8 | **Furniture selection** | 2017-10-23 A → 2017-10-24 A (+1d) | 2017-11-06 A → 2017-11-09 (+3d) | 10.5d → 13d | 100% → 79% | none → 10d |  | baseline start none → 2017-10-24; baseline finish none → 2017-11-09 |
| 9 | Preview furniture selections | 2017-10-23 A → 2017-10-24 A (+1d) | 2017-10-24 A → 2017-10-27 A (+3d) | 2d → 4d |  |  |  | resources Office Manager; Operations Manager; Administrative Assistant → Office Manager; Administrative Assistant; baseline start none → 2017-10-24; baseline finish none → 2017-10-27 |
| 10 | Select new furniture | 2017-10-24 A → 2017-10-30 A (+6d) | 2017-10-25 A → 2017-10-31 A (+6d) | 1.5d → 2d |  |  |  | resources Office Manager; Operations Manager → Office Manager; baseline start none → 2017-10-30; baseline finish none → 2017-10-31 |
| 11 | Order new furniture | 2017-10-25 A → 2017-10-31 A (+6d) | 2017-10-25 A → 2017-10-31 A (+6d) |  |  |  |  | baseline start none → 2017-10-31; baseline finish none → 2017-10-31 |
| 12 | Delivery time | 2017-10-26 A → 2017-10-31 A (+5d) | 2017-11-06 A → 2017-11-09 (+3d) |  | 100% → 60% | none → 10d |  | constraint finish no earlier than 2015-11-04 → finish no earlier than 2013-11-03; baseline start none → 2017-10-31; baseline finish none → 2017-11-09 |
| 13 | Furniture delivered | 2017-11-03 A → 2017-11-09 (+6d) | 2017-11-03 A → 2017-11-09 (+6d) |  | 100% → 0% | none → 10d |  | baseline start none → 2017-11-09; baseline finish none → 2017-11-09 |
| 14 | **Remodel workspace** |  | 2017-11-07 A |  | 94% → 100% | 6d → none |  | baseline start none → 2017-10-25; baseline finish none → 2017-11-07 |
| 15 | Hire contractor |  |  |  |  |  |  | baseline start none → 2017-10-25; baseline finish none → 2017-10-30 |
| 16 | Remodel workspace |  | 2017-11-06 A |  | 90% → 100% | 1.5d → none |  | baseline start none → 2017-10-31; baseline finish none → 2017-11-06 |
| 17 | Remodel complete | 2017-11-07 A | 2017-11-07 A |  | 0% → 100% | 6d → none |  | constraint start no earlier than 2017-11-07 → none; baseline start none → 2017-11-07; baseline finish none → 2017-11-07 |
| 18 | **New workspace** | 2017-10-25 A → 2017-11-07 A (+13d) | 2017-11-14 → 2017-11-23 (+9d) | 15d → 12.5d | 57% → 17% | 0d → 0.5d | none → 14 | baseline start none → 2017-11-07; baseline finish none → 2017-11-23 |
| 19 | Hire mover | 2017-10-25 A → 2017-11-07 A (+13d) | 2017-10-30 A → 2017-11-08 (+9d) | 4d → 2d | 100% → 75% | none → 2.33d |  | resources Office Manager → Office Manager; Operations Manager; baseline start none → 2017-11-07; baseline finish none → 2017-11-08 |
| 20 | Pack workspace | 2017-10-31 A → 2017-11-13 A (+13d) | 2017-10-31 A → 2017-11-14 (+14d) | 1d → 1.5d | 100% → 22% | none → -1.62d |  | resources President; Janitor → Operations Manager; Janitor; baseline start none → 2017-11-13; baseline finish none → 2017-11-14 |
| 21 | Move Equipment | 2017-10-31 A → 2017-11-14 (+14d) | 2017-10-31 A → 2017-11-14 (+14d) |  | 100% → 0% | none → -1.62d |  | resources Mover; Operations Manager → Mover; Office Manager; baseline start none → 2017-11-14; baseline finish none → 2017-11-14 |
| 22 | Remove existing furniture | 2017-11-01 A → 2017-11-14 (+13d) | 2017-11-01 A → 2017-11-15 (+14d) |  | 100% → 0% | none → -1d |  | baseline start none → 2017-11-14; baseline finish none → 2017-11-15 |
| 23 | Assemble new furniture | 2017-11-07 → 2017-11-16 (+9d) | 2017-11-08 → 2017-11-17 (+9d) |  |  | 1.5d → -2d |  | resources Office Manager; Space Planner [116.7%] → Office Manager; Space Planner [125%]; baseline start none → 2017-11-16; baseline finish none → 2017-11-17 |
| 24 | Return equipment | 2017-11-08 → 2017-11-17 (+9d) | 2017-11-09 → 2017-11-20 (+11d) |  |  | 1.5d → 0.5d |  | baseline start none → 2017-11-17; baseline finish none → 2017-11-20 |
| 25 | Unpack workspace | 2017-11-13 → 2017-11-20 (+7d) | 2017-11-13 → 2017-11-22 (+9d) | 1d → 2d |  | 0d → 0.5d |  | constraint start no earlier than 2017-11-11 → none; baseline start none → 2017-11-20; baseline finish none → 2017-11-22 |
| 26 | Workspace final clean | 2017-11-14 → 2017-11-22 (+8d) | 2017-11-14 → 2017-11-23 (+9d) |  |  | 0d → 0.5d |  | constraint start no earlier than 2017-11-11 → none; baseline start none → 2017-11-22; baseline finish none → 2017-11-23 |
| 27 | Workspace remodel complete | 2017-11-15 → 2017-11-24 (+9d) | 2017-11-15 → 2017-11-24 (+9d) |  |  |  | 18 → 26 | constraint start no earlier than 2017-11-15 → must finish on 2017-11-24; baseline start none → 2017-11-24; baseline finish none → 2017-11-24 |
